# GD-11 - moeilijk gevelmetselwerk

Schedule from MS Project, 2003-01-12 to 2003-03-02, status date 2003-01-08.
BAM Nelissen Van Egteren

## Calendars

- ALLEEN WERKDAGEN: Mon-Fri 08:30-12:30, 13:00-17:00; Sat-Sun off. Exceptions (off unless hours are given): 2003-01-11 to 2003-01-12 08:30-12:30, 13:00-17:00, 2003-01-18 to 2003-01-19 08:30-12:30, 13:00-17:00, 2003-01-25 to 2003-01-26 08:30-12:30, 13:00-17:00, 2003-02-01 to 2003-02-02 08:30-12:30, 13:00-17:00, 2003-02-08 to 2003-02-09 08:30-12:30, 13:00-17:00, 2003-02-15 to 2003-02-16 08:30-12:30, 13:00-17:00, 2003-02-22 to 2003-02-23 08:30-12:30, 13:00-17:00, 2003-03-01 to 2003-03-02 08:30-12:30, 13:00-17:00.

## Schedule

| ID | WBS | Task | Type | Duration | Start | Finish | Predecessors | Total slack | Free slack |
| --- | --- | --- | --- | --- | --- | --- | --- | --- | --- |
| 1 | 1 | **GEVEL/DAK FASE** |  | 50d | 2003-01-12 | 2003-03-02 |  | 0d |  |
| 2 | 1.1 | beg.grond kozijnen+profielen |  | 3d | 2003-01-12 | 2003-01-14 |  | 0d |  |
| 3 | 1.2 | beg.grond metselen gevel |  | 8d | 2003-01-14 | 2003-01-21 | 2SS+2d | 0d |  |
| 4 | 1.3 | steiger opbouwen |  | 3d | 2003-01-20 | 2003-01-22 | 3SS+6d | 0d |  |
| 5 | 1.4 | 1e verd. kozijnen+profielen |  | 3d | 2003-01-21 | 2003-01-23 | 4SS+1d | 0d |  |
| 6 | 1.5 | 1e verd. metselen gevel |  | 8d | 2003-01-22 | 2003-01-29 | 5SS+1d | 0d |  |
| 7 | 1.6 | steiger opbouwen |  | 3d | 2003-01-28 | 2003-01-30 | 6SS+6d | 0d |  |
| 8 | 1.7 | 2e verd. kozijnen+profielen |  | 3d | 2003-01-29 | 2003-01-31 | 7SS+1d | 0d |  |
| 9 | 1.8 | 2e verd. metselen gevel |  | 8d | 2003-01-30 | 2003-02-06 | 8SS+1d | 0d |  |
| 10 | 1.9 | steiger opbouwen |  | 3d | 2003-02-05 | 2003-02-07 | 9SS+6d | 0d |  |
| 11 | 1.10 | 3e verd. kozijnen+profielen |  | 3d | 2003-02-06 | 2003-02-08 | 10SS+1d | 0d |  |
| 12 | 1.11 | 3e verd. metselen gevel |  | 8d | 2003-02-07 | 2003-02-14 | 11SS+1d | 0d |  |
| 13 | 1.12 | steiger opbouwen |  | 3d | 2003-02-13 | 2003-02-15 | 12SS+6d | 0d |  |
| 14 | 1.13 | 4e verd. kozijnen+profielen |  | 3d | 2003-02-14 | 2003-02-16 | 13SS+1d | 0d |  |
| 15 | 1.14 | 4e verd. metselen gevel |  | 8d | 2003-02-15 | 2003-02-22 | 14SS+1d | 0d |  |
| 16 | 1.15 | voegen van boven naar beneden |  | 8d | 2003-02-19 | 2003-02-26 | 15SS+4d | 0d |  |
| 17 | 1.16 | steiger demonteren |  | 8d | 2003-02-22 | 2003-03-01 | 16SS+3d | 0d |  |
| 18 | 1.17 | glas plaatsen vanaf steiger |  | 8d | 2003-02-23 | 2003-03-02 | 17SS+1d | 0d |  |
| 19 | 1.18 | dak randen+opstortingen |  | 5d | 2003-01-12 | 2003-01-16 | 2SS | 13d | 0d |
| 20 | 1.19 | dakopbouw staalconstructie |  | 5d | 2003-01-15 | 2003-01-19 | 19SS+3d | 13d | 0d |
| 21 | 1.20 | dakopbouw gevelbeplating |  | 5d | 2003-01-20 | 2003-01-24 | 20 | 13d | 0d |
| 22 | 1.21 | dakopbouw dakbeplating |  | 5d | 2003-01-23 | 2003-01-27 | 21SS+3d | 13d | 0d |
| 23 | 1.22 | dakopbouw dakbedekking |  | 5d | 2003-01-28 | 2003-02-01 | 22 | 13d | 0d |
| 24 | 1.23 | platdak cement afschotlaag |  | 5d | 2003-02-01 | 2003-02-05 | 23SS+4d | 13d | 0d |
| 25 | 1.24 | plat dak droogtijd cementafschot |  | 5d | 2003-02-05 | 2003-02-09 | 24SS+4d | 13d | 0d |
| 26 | 1.25 | platdak isolatieplaten aanbr, |  | 5d | 2003-02-09 | 2003-02-13 | 25SS+4d | 13d | 0d |
| 27 | 1.26 | platdak dakbedekking aanbr. |  | 5d | 2003-02-13 | 2003-02-17 | 26SS+4d | 13d |  |
| 28 | 1.27 | start afbouw fase | milestone | 0d | 2003-03-02 | 2003-03-02 | 18SS+8d | 0d |  |
